# Atlas_Disk_Sector

Schedule from MS Project, 2001-01-15 to 2002-08-19.
eng

## Calendars

- Standard: Mon-Fri 08:00-12:00, 13:00-17:00; Sat-Sun off. Exceptions (off unless hours are given): 2001-02-19, 2001-05-28, 2001-07-04, 2001-09-03, 2001-11-22 to 2001-11-23, 2001-12-24 to 2001-12-28, 2001-12-31 to 2002-01-01, 2002-01-14, 2002-02-18, 2002-03-07 08:00-12:00, 13:00-17:00, 2002-05-27.

## Schedule

| ID | WBS | Task | Type | Duration | Start | Finish | Predecessors | Total slack | Free slack | Constraint |
| --- | --- | --- | --- | --- | --- | --- | --- | --- | --- | --- |
| 1 | 1 | **Materials Fabrication / Procurement** |  | 149d | 2001-01-15 | 2001-08-15 |  | 119d |  |  |
| 2 | 1.1 | **Carbon-carbon Plates (6507002)** |  | 142d | 2001-01-15 | 2001-08-06 |  | 0d |  |  |
| 3 | 1.1.1 | Complete Spec | milestone | 0d | 2001-01-15 | 2001-01-15 |  | 142d | 12d | start no earlier than 2001-01-15 |
| 4 | 1.1.2 | Issue Purchase Order | milestone | 0d | 2001-01-31 | 2001-01-31 | 3 | 130d |  | start no earlier than 2001-01-31 |
| 5 | 1.1.3 | Receive Plates | milestone | 0d | 2001-08-06 | 2001-08-06 | 4 | 0d |  | start no earlier than 2001-08-06 |
| 6 | 1.2 | **Aluminum Tube (6507269)** |  | 116d | 2001-01-15 | 2001-06-28 |  | 26d |  |  |
| 7 | 1.2.1 | Complete Spec | milestone | 0d | 2001-01-15 | 2001-01-15 |  | 142d | 25d | start no earlier than 2001-01-15 |
| 8 | 1.2.2 | Issue Purchase Order | milestone | 0d | 2001-02-20 | 2001-02-20 | 7 | 117d | 91d | start no earlier than 2001-02-20 |
| 9 | 1.2.3 | Receive Tubes | milestone | 0d | 2001-06-28 | 2001-06-28 | 8 | 26d |  | start no earlier than 2001-06-28 |
| 10 | 1.3 | **Carbon Foam** |  | 43d | 2001-04-16 | 2001-06-15 |  | 50d |  |  |
| 11 | 1.3.1 | Complete Spec | milestone | 0d | 2001-04-16 | 2001-04-16 |  | 55d | 0d | start no earlier than 2001-04-16 |
| 12 | 1.3.2 | Issue Purchase Order | milestone | 0d | 2001-04-25 | 2001-04-25 | 11FS+8d | 55d | 0d | start no earlier than 2001-04-23 |
| 13 | 1.3.3 | Procure and CVD |  | 30d | 2001-04-26 | 2001-06-07 | 12 | 55d | 5d |  |
| 14 | 1.3.4 | Receive Carbon Foam | milestone | 0d | 2001-06-15 | 2001-06-15 | 13 | 50d | 0d | start no earlier than 2001-06-15 |
| 15 | 1.4 | **Cyanate Ester Adhesive** |  | 117d | 2001-02-17 | 2001-08-06 |  | 13d |  |  |
| 16 | 1.4.1 | Complete Spec | milestone | 0d | 2001-02-17 | 2001-02-17 |  | 130d | 94d |  |
| 17 | 1.4.2 | Issue Purchase Order | milestone | 0d | 2001-07-03 | 2001-07-03 | 16 | 36d | 23d | start no earlier than 2001-07-03 |
| 18 | 1.4.3 | Receive Adhesive | milestone | 0d | 2001-08-06 | 2001-08-06 | 17 | 13d | 0d | start no earlier than 2001-08-06 |
| 19 | 1.5 | **Thermal Compound** |  | 73d | 2001-05-02 | 2001-08-15 |  | 251d |  |  |
| 20 | 1.5.1 | Select Material | milestone | 0d | 2001-05-02 | 2001-05-02 |  | 324d | 43d | start no earlier than 2001-05-02 |
| 21 | 1.5.2 | Issue Purchase Order | milestone | 0d | 2001-07-03 | 2001-07-03 | 20 | 281d | 30d | start no earlier than 2001-07-03 |
| 22 | 1.5.3 | Receive Compound | milestone | 0d | 2001-08-15 | 2001-08-15 | 21 | 251d |  | start no earlier than 2001-08-15 |
| 23 | 1.6 | **Misc. Components** |  | 21d | 2001-06-01 | 2001-07-02 |  | 282d |  |  |
| 24 | 1.6.1 | Complete Specs | milestone | 0d | 2001-06-01 | 2001-06-01 |  | 295d | 13d | start no earlier than 2001-06-01 |
| 25 | 1.6.2 | Issue Purchase Orders | milestone | 0d | 2001-07-02 | 2001-07-02 | 24FS+8d | 282d |  | start no earlier than 2001-07-02 |

| ID | WBS | Task | Type | Duration | Start | Finish | Predecessors | Total slack | Free slack | Constraint |
| --- | --- | --- | --- | --- | --- | --- | --- | --- | --- | --- |
| 26 | 2 | **Prototype** |  | 104d | 2001-02-17 | 2001-07-17 |  | 23d |  |  |
| 27 | 2.1 | Start Fabrication of Prototype | milestone | 0d | 2001-02-17 | 2001-02-17 |  | 32d | 0d |  |
| 28 | 2.2 | Fabrication of Strain Relief |  | 2d | 2001-02-20 | 2001-02-21 | 27 | 42d | 0d |  |
| 29 | 2.3 | Inspection & Cleaning |  | 2d | 2001-02-22 | 2001-02-23 | 28 | 42d | 19d |  |
| 30 | 2.4 | Fabrication of T-Washers |  | 2d | 2001-02-20 | 2001-02-21 | 27 | 48d | 0d |  |
| 31 | 2.5 | Inspection & Cleaning |  | 2d | 2001-02-22 | 2001-02-23 | 30 | 48d | 25d |  |
| 32 | 2.6 | Fabrication of Hard Points |  | 2d | 2001-02-20 | 2001-02-21 | 27 | 34d | 0d |  |
| 33 | 2.7 | Inspection & Cleaning |  | 2d | 2001-02-22 | 2001-02-23 | 32 | 34d | 2d |  |
| 34 | 2.8 | Fabrication of 12 Tube Ends Fittings |  | 2d | 2001-03-06 | 2001-03-07 | 27 | 30d | 0d | start no earlier than 2001-03-06 |
| 35 | 2.9 | Inspection & Cleaning |  | 2d | 2001-03-08 | 2001-03-09 | 34 | 30d | 0d |  |
| 36 | 2.10 | Chromic Acid Etch |  | 1d | 2001-03-12 | 2001-03-12 | 35 | 30d | 0d |  |
| 37 | 2.11 | Re-inspection |  | 1d | 2001-03-13 | 2001-03-13 | 36 | 30d | 7d |  |
| 38 | 2.12 | Carbon Sheets |  | 2d | 2001-02-20 | 2001-02-21 | 27 | 32d | 0d |  |
| 39 | 2.13 | Rough Cut Face Sheets |  | 1d | 2001-02-22 | 2001-02-22 | 38 | 32d | 0d |  |
| 40 | 2.14 | Fab of Face Sheets |  | 2d | 2001-02-23 | 2001-02-26 | 39 | 32d | 0d |  |
| 41 | 2.15 | Inspection & Cleaning |  | 1d | 2001-02-27 | 2001-02-27 | 40 | 32d | 0d |  |
| 42 | 2.16 | Mount Hard Points to Face Sheets |  | 2d | 2001-02-28 | 2001-03-01 | 41, 33 | 32d | 0d |  |
| 43 | 2.17 | Bake Assembly |  | 2d | 2001-03-02 | 2001-03-05 | 42 | 32d | 0d |  |
| 44 | 2.18 | Inspect & Clean 6 Face Sheets |  | 1d | 2001-03-06 | 2001-03-06 | 43 | 32d | 0d |  |
| 45 | 2.19 | Foam Rough Cut & Prep for Bonding |  | 2d | 2001-02-22 | 2001-02-23 | 38 | 39d | 7d | start no earlier than 2001-02-21 |
| 46 | 2.20 | Cutting Cyanate Ester |  | 2d | 2001-02-22 | 2001-02-23 | 38 | 39d | 7d |  |
| 47 | 2.21 | Foam & Cyanate Bonding to 3 Face Sheets |  | 2d | 2001-03-07 | 2001-03-08 | 46, 44, 45 | 32d | 0d |  |
| 48 | 2.22 | Cut Tube Profiles & T-Wash Holes |  | 2d | 2001-03-09 | 2001-03-12 | 47 | 32d | 0d |  |
| 49 | 2.23 | Inspection & Cleaning |  | 2d | 2001-03-13 | 2001-03-14 | 48 | 32d | 9d |  |
| 50 | 2.24 | Bend Tubes |  | 3d | 2001-03-07 | 2001-03-09 | 27 | 23d | 0d | start no earlier than 2001-03-07 |
| 51 | 2.25 | Remove Wax |  | 2d | 2001-03-08 | 2001-03-09 | 50SS+1d | 23d | 0d |  |
| 52 | 2.26 | Inspection & Cleaning |  | 1d | 2001-03-12 | 2001-03-12 | 51 | 23d | 0d |  |
| 53 | 2.27 | Hydroform Tubes |  | 4d | 2001-03-13 | 2001-03-16 | 52 | 23d | 0d |  |
| 54 | 2.28 | Inspection & Clean |  | 4d | 2001-03-14 | 2001-03-19 | 53SS+1d | 23d | 0d |  |
| 55 | 2.29 | Trim to Length |  | 4d | 2001-03-15 | 2001-03-20 | 54SS+1d | 23d | 0d |  |
| 56 | 2.30 | Swage Ends |  | 4d | 2001-03-16 | 2001-03-21 | 55SS+1d | 23d | 0d |  |
| 57 | 2.31 | Inspection & Cleaning |  | 1d | 2001-03-22 | 2001-03-22 | 56 | 23d | 0d |  |
| 58 | 2.32 | Bond Tube End Fittings & Strain Reliefs |  | 3d | 2001-03-23 | 2001-03-27 | 37, 29, 57 | 23d | 0d |  |
| 59 | 2.33 | Leak Test |  | 1d | 2001-03-26 | 2001-03-26 | 58SS+1d | 23d | 0d |  |
| 60 | 2.34 | Inspect & Clean |  | 1d | 2001-03-27 | 2001-03-27 | 59 | 23d | 0d |  |
| 61 | 2.35 | Sector Assembly |  | 3d | 2001-03-28 | 2001-03-30 | 49, 44, 60 | 23d | 0d |  |
| 62 | 2.36 | Bake Period |  | 3d | 2001-03-29 | 2001-04-02 | 61SS+1d | 23d | 0d |  |
| 63 | 2.37 | Inspect |  | 3d | 2001-03-30 | 2001-04-03 | 62SS+1d | 23d | 0d |  |
| 64 | 2.38 | Bond T-Washers to Sector Assembly |  | 3d | 2001-04-02 | 2001-04-04 | 63SS+1d, 31 | 23d | 0d |  |
| 65 | 2.39 | Face Cut T-Washers to Sector Assy. |  | 1d | 2001-04-05 | 2001-04-05 | 64 | 23d | 0d |  |
| 66 | 2.40 | Final Inspect |  | 1d | 2001-04-06 | 2001-04-06 | 65 | 23d | 0d |  |
| 67 | 2.41 | Test Verification |  | 70d | 2001-04-09 | 2001-07-17 | 66 | 23d | 0d | start no earlier than 2001-04-09 |
| 68 | 2.42 | Revise Model for Production |  | 55d | 2001-04-16 | 2001-07-02 | 67SS+5d | 23d |  | start no earlier than 2001-04-16 |

| ID | WBS | Task | Type | Duration | Start | Finish | Predecessors | Total slack | Free slack | Constraint |
| --- | --- | --- | --- | --- | --- | --- | --- | --- | --- | --- |
| 69 | 3 | **Pre-Production** |  | 151d | 2001-08-06 | 2002-03-20 | 68, 5, 9 | 0d |  |  |
| 70 | 3.1 | **Tooling** |  | 32d | 2001-08-06 | 2001-09-19 |  | 0d |  |  |
| 71 | 3.1.1 | Tube End Bonding Fixture |  | 7d | 2001-08-06 | 2001-08-14 |  | 0d |  | start no earlier than 2001-04-09 |
| 72 | 3.1.2 | Swaging Tools |  | 4d | 2001-08-09 | 2001-08-14 | 71SS+3d | 0d |  |  |
| 73 | 3.1.3 | Modify Tube Bend Fixture |  | 7d | 2001-08-13 | 2001-08-21 | 72SS+2d | 0d |  |  |
| 74 | 3.1.4 | Tube Cleaning Apparatus |  | 3d | 2001-08-16 | 2001-08-20 | 73SS+3d | 0d |  |  |
| 75 | 3.1.5 | Tube Anodize Fixture |  | 6d | 2001-08-17 | 2001-08-24 | 74SS+1d | 0d |  |  |
| 76 | 3.1.6 | Tube Hydroform Fixture |  | 7d | 2001-08-21 | 2001-08-29 | 75SS+2d | 0d |  |  |
| 77 | 3.1.7 | Strain Relief Bonding Fixture |  | 3d | 2001-08-23 | 2001-08-27 | 76SS+2d | 0d |  |  |
| 78 | 3.1.8 | Hard Point Bonding Fixture |  | 12d | 2001-08-24 | 2001-09-11 | 77SS+1d | 0d |  |  |
| 79 | 3.1.9 | Sector Bond Fixture |  | 6d | 2001-08-30 | 2001-09-07 | 78SS+4d | 0d |  |  |
| 80 | 3.1.10 | T-washer Bond Fixture |  | 3d | 2001-09-04 | 2001-09-06 | 79SS+2d | 0d |  |  |
| 81 | 3.1.11 | Parts Cleaning Fixturing |  | 4d | 2001-09-05 | 2001-09-10 | 80SS+1d | 0d |  |  |
| 82 | 3.1.12 | Tooling for Parylene Coat |  | 6d | 2001-09-06 | 2001-09-13 | 81SS+1d | 0d |  |  |
| 83 | 3.1.13 | Sector Production Area Setup |  | 7d | 2001-09-11 | 2001-09-19 | 82SS+3d | 0d |  |  |
| 84 | 3.2 | Start Fabrication of Pre-Production Sectors | milestone | 0d | 2001-09-19 | 2001-09-19 | 83 | 0d |  | start no earlier than 2001-05-10 |
| 85 | 3.3 | Fabrication of Strain Relief |  | 15d | 2001-09-20 | 2001-10-10 | 84 | 18d | 0d |  |
| 86 | 3.4 | Inspection & Cleaning |  | 1d | 2001-10-11 | 2001-10-11 | 85 | 18d |  |  |
| 87 | 3.5 | Fabrication of T-Washers |  | 15d | 2001-09-20 | 2001-10-10 | 84 | 26d | 0d |  |
| 88 | 3.6 | Inspection & Cleaning |  | 1d | 2001-10-11 | 2001-10-11 | 87 | 26d |  |  |
| 89 | 3.7 | Fabrication of Hard Points |  | 15d | 2001-09-20 | 2001-10-10 | 84 | 3d | 0d | start no earlier than 2001-04-23 |
| 90 | 3.8 | Inspection & Cleaning |  | 1d | 2001-10-11 | 2001-10-11 | 89 | 3d | 0d |  |
| 91 | 3.9 | Fabrication of Tube Ends Fittings |  | 15d | 2001-09-20 | 2001-10-10 | 84 | 16d | 0d | start no earlier than 2001-04-20 |
| 92 | 3.10 | Inspection & Cleaning |  | 1d | 2001-10-11 | 2001-10-11 | 91 | 16d |  |  |
| 93 | 3.11 | Inspect Carbon-Carbon Sheets |  | 1d | 2001-09-20 | 2001-09-20 | 84 | 11d | 0d |  |
| 94 | 3.12 | Rough Cut 20 Face Sheets |  | 2d | 2001-09-21 | 2001-09-24 | 93 | 11d | 0d |  |
| 95 | 3.13 | Fab of Face Sheets |  | 4d | 2001-09-25 | 2001-09-28 | 94 | 11d | 0d |  |
| 96 | 3.14 | Inspection & Cleaning |  | 1d | 2001-10-01 | 2001-10-01 | 95 | 11d | 8d |  |
| 97 | 3.15 | Mount Hard Points to Face Sheets |  | 5d | 2001-10-12 | 2001-10-18 | 90, 96 | 3d | 0d |  |
| 98 | 3.16 | Bake Assembly |  | 5d | 2001-10-19 | 2001-10-25 | 97 | 3d | 0d |  |
| 99 | 3.17 | Inspect 20 Face Sheets |  | 1d | 2001-10-26 | 2001-10-26 | 98 | 3d | 0d |  |
| 100 | 3.18 | Inspect Foam |  | 1d | 2001-08-17 | 2001-08-17 | 14FS+44d | 50d | 0d | start no earlier than 2001-02-21 |
| 101 | 3.19 | Rough Cut Foam & Prep for Bonding |  | 2d | 2001-08-20 | 2001-08-21 | 100 | 50d | 47d |  |
| 102 | 3.20 | Cutting Cyanate Ester |  | 2d | 2001-10-11 | 2001-10-12 | 18FS+47d | 13d | 10d |  |
| 103 | 3.21 | Foam & Cyanate Bonding to 10 Face Sheets |  | 5d | 2001-10-29 | 2001-11-02 | 99, 100, 102, 101 | 3d | 0d |  |
| 104 | 3.22 | Cut Tube Profiles & T-Wash Holes |  | 3d | 2001-11-01 | 2001-11-05 | 103SS+3d | 3d | 0d |  |
| 105 | 3.23 | Inspection & Cleaning |  | 3d | 2001-11-06 | 2001-11-08 | 104 | 3d |  |  |
| 106 | 3.24 | Inspect & Clean Al Tubes |  | 3d | 2001-08-06 | 2001-08-08 | 9 | 29d |  | start no earlier than 2001-05-14 |
| 107 | 3.25 | Bend Tubes |  | 10d | 2001-09-20 | 2001-10-03 | 84, 106 | 0d |  | start no earlier than 2001-03-07 |
| 108 | 3.26 | Remove Wax |  | 10d | 2001-09-21 | 2001-10-04 | 107SS+1d | 0d |  |  |
| 109 | 3.27 | Inspection & Cleaning |  | 10d | 2001-09-24 | 2001-10-05 | 108SS+1d | 0d |  |  |
| 110 | 3.28 | Hydroform Tubes |  | 10d | 2001-10-08 | 2001-10-19 | 109 | 0d |  |  |
| 111 | 3.29 | Inspection & Clean |  | 10d | 2001-10-09 | 2001-10-22 | 110SS+1d | 0d |  |  |
| 112 | 3.30 | Trim to Length |  | 10d | 2001-10-10 | 2001-10-23 | 111SS+1d | 0d |  |  |
| 113 | 3.31 | Swage Ends |  | 10d | 2001-10-11 | 2001-10-24 | 112SS+1d | 0d |  |  |
| 114 | 3.32 | Inspection & Cleaning |  | 2d | 2001-10-25 | 2001-10-26 | 113 | 0d |  |  |
| 115 | 3.33 | Prep for Anodize |  | 3d | 2001-10-29 | 2001-10-31 | 114 | 0d |  |  |
| 116 | 3.34 | Anodize Tubes |  | 2d | 2001-11-01 | 2001-11-02 | 115 | 0d |  |  |
| 117 | 3.35 | Chromic Acid Etch Tube End Fittings |  | 2d | 2001-11-05 | 2001-11-06 | 116, 92 | 0d |  |  |
| 118 | 3.36 | Chromic Acid Etch Tube Ends |  | 2d | 2001-11-05 | 2001-11-06 | 116 | 0d |  |  |
| 119 | 3.37 | Bond Tube End Fittings & Strain Reliefs |  | 2d | 2001-11-07 | 2001-11-08 | 86, 117, 118 | 0d |  |  |
| 120 | 3.38 | Leak Test |  | 3d | 2001-11-08 | 2001-11-12 | 119SS+1d | 0d |  |  |
| 121 | 3.39 | Inspect & Clean |  | 1d | 2001-11-13 | 2001-11-13 | 120 | 0d |  |  |
| 122 | 3.40 | Sector Assembly |  | 12d | 2001-11-14 | 2001-12-03 | 99, 105, 121 | 0d |  |  |
| 123 | 3.41 | Bake Period |  | 12d | 2001-11-15 | 2001-12-04 | 122SS+1d | 0d |  |  |
| 124 | 3.42 | Inspect |  | 12d | 2001-11-16 | 2001-12-05 | 123SS+1d | 0d |  |  |
| 125 | 3.43 | Bond T-Washers to Sector Assembly |  | 12d | 2001-11-19 | 2001-12-06 | 88, 124SS+1d | 0d |  |  |
| 126 | 3.44 | Face Cut T-Washers to Sector Assy. |  | 3d | 2001-12-07 | 2001-12-11 | 125 | 0d |  |  |
| 127 | 3.45 | Inspect |  | 1d | 2001-12-12 | 2001-12-12 | 126 | 0d |  |  |
| 128 | 3.46 | Prepare Sectors for Parylene Coating |  | 2d | 2001-12-13 | 2001-12-14 | 127 | 0d |  |  |
| 129 | 3.47 | Parylene Coating |  | 6d | 2001-12-17 | 2002-01-02 | 128 | 0d |  |  |
| 130 | 3.48 | Final Inspection |  | 3d | 2002-01-03 | 2002-01-07 | 129 | 107d | 0d |  |
| 131 | 3.49 | Test Verification |  | 50d | 2002-01-08 | 2002-03-20 | 130 | 107d |  |  |

| ID | WBS | Task | Type | Duration | Start | Finish | Predecessors | Total slack | Free slack | Constraint |
| --- | --- | --- | --- | --- | --- | --- | --- | --- | --- | --- |
| 132 | 4 | **Production** |  | 160d | 2002-01-02 | 2002-08-19 | 129 | 0d |  |  |
| 133 | 4.1 | Start Fabrication of Production Sectors | milestone | 0d | 2002-01-02 | 2002-01-02 |  | 0d |  | start no earlier than 2001-08-23 |
| 134 | 4.2 | Rough Cut 100 Face Sheets |  | 6d | 2002-01-03 | 2002-01-10 | 133 | 0d |  |  |
| 135 | 4.3 | Fab of Face Sheets |  | 12d | 2002-01-11 | 2002-01-29 | 134 | 0d |  |  |
| 136 | 4.4 | Inspection & Cleaning |  | 2d | 2002-01-30 | 2002-01-31 | 135 | 0d |  |  |
| 137 | 4.5 | Mount Hard Points to Face Sheets |  | 25d | 2002-02-01 | 2002-03-08 | 136, 90 | 0d |  |  |
| 138 | 4.6 | Bake Assembly |  | 25d | 2002-02-01 | 2002-03-08 | 137SS | 0d |  |  |
| 139 | 4.7 | Inspect Face Sheets |  | 25d | 2002-02-04 | 2002-03-11 | 138SS+1d | 0d |  |  |
| 140 | 4.8 | Rough Cut Foam & Prep for Bonding |  | 15d | 2002-01-03 | 2002-01-24 | 133 | 26d | 0d |  |
| 141 | 4.9 | Cutting Cyanate Ester |  | 5d | 2002-01-25 | 2002-01-31 | 140 | 26d |  |  |
| 142 | 4.10 | Foam & Cyanate Bonding to Face Sheets |  | 25d | 2002-03-12 | 2002-04-15 | 139, 140, 141 | 0d |  |  |
| 143 | 4.11 | Cut Tube Profiles & T-Wash Holes |  | 15d | 2002-03-27 | 2002-04-16 | 142SS+11d | 0d |  |  |
| 144 | 4.12 | Inspection & Cleaning |  | 15d | 2002-03-28 | 2002-04-17 | 143SS+1d | 0d |  |  |
| 145 | 4.13 | Bend Tubes |  | 50d | 2002-01-03 | 2002-03-15 | 133 | 0d |  | start no earlier than 2001-03-07 |
| 146 | 4.14 | Remove Wax |  | 50d | 2002-01-04 | 2002-03-18 | 145SS+1d | 0d |  |  |
| 147 | 4.15 | Inspection & Cleaning |  | 50d | 2002-01-07 | 2002-03-19 | 146SS+1d | 0d |  |  |
| 148 | 4.16 | Hydroform Tubes |  | 50d | 2002-01-08 | 2002-03-20 | 147SS+1d | 0d |  |  |
| 149 | 4.17 | Inspection & Clean |  | 50d | 2002-01-09 | 2002-03-21 | 148SS+1d | 0d |  |  |
| 150 | 4.18 | Trim to Length |  | 50d | 2002-01-10 | 2002-03-22 | 149SS+1d | 0d |  |  |
| 151 | 4.19 | Swage Ends |  | 50d | 2002-01-11 | 2002-03-25 | 150SS+1d | 0d |  |  |
| 152 | 4.20 | Inspection & Cleaning |  | 50d | 2002-01-15 | 2002-03-26 | 151SS+1d | 0d |  |  |
| 153 | 4.21 | Prep for Anodize |  | 43d | 2002-01-29 | 2002-03-29 | 152SS+10d | 0d |  |  |
| 154 | 4.22 | Anodize Tubes |  | 43d | 2002-01-31 | 2002-04-02 | 153SS+2d | 0d |  |  |
| 155 | 4.23 | Chromic Acid Etch Tube End Fittings |  | 10d | 2002-04-03 | 2002-04-16 | 154, 92 | 0d |  |  |
| 156 | 4.24 | Chromic Acid Etch Tube Ends |  | 10d | 2002-04-03 | 2002-04-16 | 154 | 0d |  |  |
| 157 | 4.25 | Bond Tube End Fittings & Strain Reliefs |  | 10d | 2002-04-03 | 2002-04-16 | 86, 156SS, 155SS | 0d |  |  |
| 158 | 4.26 | Leak Test |  | 10d | 2002-04-04 | 2002-04-17 | 157SS+1d | 0d |  |  |
| 159 | 4.27 | Inspect & Clean |  | 5d | 2002-04-11 | 2002-04-17 | 158SS+5d | 0d |  |  |
| 160 | 4.28 | Sector Assembly |  | 25d | 2002-04-18 | 2002-05-22 | 139, 144, 159 | 0d |  |  |
| 161 | 4.29 | Bake Period |  | 25d | 2002-04-19 | 2002-05-23 | 160SS+1d | 0d |  |  |
| 162 | 4.30 | Inspect |  | 25d | 2002-04-22 | 2002-05-24 | 161SS+1d | 0d |  |  |
| 163 | 4.31 | Bond T-Washers to Sector Assembly |  | 25d | 2002-04-23 | 2002-05-28 | 162SS+1d, 88 | 39d | 0d |  |
| 164 | 4.32 | Face Cut T-Washers to Sector Assy. |  | 22d | 2002-04-30 | 2002-05-30 | 163SS+5d | 39d | 0d |  |
| 165 | 4.33 | Inspect |  | 22d | 2002-05-01 | 2002-05-31 | 164SS+1d | 39d | 0d |  |
| 166 | 4.34 | Prepare Sectors for Parylene Coating |  | 6d | 2002-06-03 | 2002-06-10 | 165 | 39d | 0d |  |
| 167 | 4.35 | Parylene Coating |  | 6d | 2002-06-11 | 2002-06-18 | 166 | 39d | 0d |  |
| 168 | 4.36 | Final Inspection |  | 5d | 2002-06-19 | 2002-06-25 | 167 | 39d |  |  |
| 169 | 4.37 | Sample Testing |  | 80d | 2002-04-29 | 2002-08-19 | 162SS+5d | 0d |  |  |
