# Pixel_mechanics

Schedule from MS Project, 2000-09-07 to 2005-12-12.
LBNL

## Calendars

- Standard: Mon-Fri 08:00-12:00, 13:00-17:00; Sat-Sun off.

## Resources

| Resource | Group | Rate |
| --- | --- | --- |
| LBLj SP PRJ | LBL | 67.53 |
| LBLj EE PRJ | LBL | 70.95 |
| LBLj ME PRJ | LBL | 70.95 |
| LBLj DS PRJ | LBL | 31.52 |
| LBLj ET PRJ | LBL | 31.52 |
| LBLj MT PRJ | LBL | 31.52 |
| LBLj AS PRJ | LBL | 30.01 |
| LBLj OA PRJ | LBL | 30.01 |
| LBLj CL PRJ | LBL | 20.02 |
| LBLj SH PRJ | LBL | 52.44 |
| LBLj TS PRJ | LBL | 52.44 |
| LBLj ST PRJ | LBL | 15.11 |
| LBLj PM PRJ | LBL | 0.11 |
| LBLj S PRJ | LBL |  |
| LBLj TR PRJ | LBL | 0.11 |
| LBLj LW PRJ | LBL | 0.11 |
| LBLj RD PRJ | LBL | 0.05 |
| LBLj HI PRJ | LBL | 0.05 |
| LBLs SP PRJ | LBL | 100 |
| LBLs EE PRJ | LBL | 105.06 |
| LBLs ME PRJ | LBL | 105.06 |
| LBLs DS PRJ | LBL | 49.96 |
| LBLs ET PRJ | LBL | 49.96 |
| LBLs MT PRJ | LBL | 49.96 |
| LBLs AS PRJ | LBL | 47.56 |
| LBLs OA PRJ | LBL | 47.56 |
| LBLs CL PRJ | LBL | 22.06 |
| LBLs SH PRJ | LBL | 52.44 |
| LBLs TS PRJ | LBL | 49.91 |
| LBLs ST PRJ | LBL | 15.11 |
| LBLs PM PRJ | LBL | 0.11 |
| LBLs S PRJ | LBL |  |
| LBLs TR PRJ | LBL | 0.11 |
| LBLs LW PRJ | LBL | 0.11 |
| LBLs RD PRJ | LBL | 0.05 |
| LBLs HI PRJ | LBL | 0.05 |
| SUNYA SP PRJ | SUNYA |  |
| SUNYA EE PRJ | SUNYA |  |
| SUNYA ME PRJ | SUNYA |  |
| SUNYA DS PRJ | SUNYA | 27.93 |
| SUNYA ET PRJ | SUNYA | 27.93 |
| SUNYA MT PRJ | SUNYA | 27.93 |
| SUNYA AS PRJ | SUNYA | 27.93 |
| SUNYA OA PRJ | SUNYA | 27.93 |
| SUNYA CL PRJ | SUNYA |  |
| SUNYA SH PRJ | SUNYA | 27.93 |
| SUNYA TS PRJ | SUNYA | 27.93 |
| SUNYA ST PRJ | SUNYA | 14.7 |
| SUNYA PM PRJ | SUNYA |  |
| SUNYA S PRJ | SUNYA |  |
| SUNYA TR PRJ | SUNYA |  |
| SUNYA LW PRJ | SUNYA |  |
| SUNYA RD PRJ | SUNYA | 0.47 |
| SUNYA HI PRJ | SUNYA |  |
| UNM SP PRJ | UNM | 40.32 |
| UNM EE PRJ | UNM | 43.95 |
| UNM ME PRJ | UNM | 40.32 |
| UNM DS PRJ | UNM | 22.68 |
| UNM ET PRJ | UNM | 22.68 |
| UNM MT PRJ | UNM | 22.68 |
| UNM AS PRJ | UNM | 22.68 |
| UNM OA PRJ | UNM | 22.68 |
| UNM CL PRJ | UNM | 18.9 |
| UNM SH PRJ | UNM | 49.14 |
| UNM TS PRJ | UNM | 49.14 |
| UNM ST PRJ | UNM | 10.99 |
| UNM PM PRJ | UNM |  |
| UNM S PRJ | UNM |  |
| UNM TR PRJ | UNM |  |
| UNM LW PRJ | UNM |  |
| UNM RD PRJ | UNM |  |
| UNM HI PRJ | UNM |  |
| UOK SP PRJ | UOK | 45.57 |
| UOK EE PRJ | UOK | 45.57 |
| UOK ME PRJ | UOK | 45.57 |
| UOK DS PRJ | UOK | 31.6 |
| UOK ET PRJ | UOK | 33.7 |
| UOK MT PRJ | UOK | 31.6 |
| UOK AS PRJ | UOK | 31.6 |
| UOK OA PRJ | UOK | 31.6 |
| UOK CL PRJ | UOK | 13.23 |
| UOK SH PRJ | UOK | 13.23 |
| UOK TS PRJ | UOK | 13.23 |
| UOK ST PRJ | UOK | 10.99 |
| UOK PM PRJ | UOK |  |
| UOK S PRJ | UOK |  |
| UOK TR PRJ | UOK | 0.15 |
| UOK LW PRJ | UOK |  |
| UOK RD PRJ | UOK |  |
| UOK HI PRJ | UOK |  |
| OSU PM PRJ | OSU |  |
| OSU LW PRJ | OSU |  |
| OSU ST PRJ | OSU | 11.61 |
| OSU ET PRJ | OSU | 36.5 |
| OSU EE PRJ | OSU | 66.36 |
| OSU CL PRJ | OSU | 21.56 |
| OSU MT PRJ | OSU | 36.5 |
| OSU HI PRJ | OSU |  |

## Schedule

| ID | WBS | Task | Type | Duration | Start | Finish | Predecessors | Total slack | Free slack | Constraint | Text1 |
| --- | --- | --- | --- | --- | --- | --- | --- | --- | --- | --- | --- |
| 1 | 1 | **Pixel Mechanics** |  | 1373d | 2000-09-07 | 2005-12-12 |  | 0d |  |  |  |
| 2 | 1.1.1.1.1 | **Design** |  | 678d | 2001-07-11 | 2004-02-16 |  | 13d |  |  |  |
| 3 | 1.1.1 | Local Support PRR | milestone | 0d | 2001-07-12 | 2001-07-12 |  | 12d | 0d | start no earlier than 2001-07-12 | LHCC |
| 4 | 1.1.2 | Disk Sector PAR | milestone | 0d | 2002-02-26 | 2002-02-26 |  | 990d |  | start no earlier than 2002-02-26 |  |
| 5 | 1.1.3 | Stave PAR | milestone | 0d | 2002-06-14 | 2002-06-14 |  | 912d |  | start no earlier than 2002-06-14 |  |
| 6 | 1.1.4 | Global & Intermediate Support CDR | milestone | 0d | 2001-07-11 | 2001-07-11 | 3FS-1d | 1154d |  |  |  |
| 7 | 1.1.5 | Global & Intermediate Support FDR | milestone | 0d | 2001-10-15 | 2001-10-15 | 3FS+65d | 10d | 0d | start no earlier than 2001-10-15 |  |
| 8 | 1.1.6 | Global & Intermediate Support PRR | milestone | 0d | 2002-02-26 | 2002-02-26 | 7FS+97d | 10d | 0d | start no earlier than 2001-12-17 | LHCC |
| 9 | 1.1.7 | Global & Intermediate Support PAR | milestone | 0d | 2002-06-14 | 2002-06-14 |  | 912d |  | start no earlier than 2002-06-14 |  |
| 10 | 1.1.8 | Support tube CDR | milestone | 0d | 2001-10-15 | 2001-10-15 | 7 | 1086d |  |  |  |
| 11 | 1.1.9 | Support tube FDR | milestone | 0d | 2002-02-26 | 2002-02-26 |  | 990d | 0d | start no earlier than 2002-02-26 |  |
| 12 | 1.1.10 | Support tube PRR | milestone | 0d | 2002-10-03 | 2002-10-03 |  | 192d | 0d | start no earlier than 2002-10-03 |  |
| 13 | 1.1.11 | Support tube PAR | milestone | 0d | 2003-02-19 | 2003-02-19 |  | 734d |  | start no earlier than 2003-02-19 |  |
| 14 | 1.1.12 | B-layer CDR | milestone | 0d | 2002-02-26 | 2002-02-26 | 8 | 989d |  |  |  |
| 15 | 1.1.13 | B-layer FDR | milestone | 0d | 2002-10-03 | 2002-10-03 | 12 | 192d | 0d |  |  |
| 16 | 1.1.14 | B-layer PRR | milestone | 0d | 2003-02-19 | 2003-02-19 | 15FS+100d | 443d | 0d |  |  |
| 17 | 1.1.15 | B-layer PAR | milestone | 0d | 2003-06-16 | 2003-06-16 |  | 651d |  | start no earlier than 2003-06-16 |  |
| 18 | 1.1.16 | Cables/services CDR | milestone | 0d | 2001-10-15 | 2001-10-15 | 7 | 291d | 0d |  |  |
| 19 | 1.1.17 | Cables/services FDR | milestone | 0d | 2002-06-14 | 2002-06-14 | 18FS+175d | 291d | 0d | start no earlier than 2001-09-03 |  |
| 20 | 1.1.18 | Cables/services PRR | milestone | 0d | 2003-02-19 | 2003-02-19 | 19FS+178d | 291d | 0d | start no earlier than 2002-04-15 |  |
| 21 | 1.1.19 | Cables/services PAR | milestone | 0d | 2003-11-26 | 2003-11-26 |  | 534d |  | start no earlier than 2003-11-26 |  |
| 22 | 1.1.20 | Assembly/Installation CDR | milestone | 0d | 2002-02-26 | 2002-02-26 | 8 | 989d |  |  |  |
| 23 | 1.1.21 | Assembly/Installation FDR | milestone | 0d | 2002-10-03 | 2002-10-03 | 15 | 192d | 0d |  |  |
| 24 | 1.1.22 | Assembly/Installation PRR | milestone | 0d | 2003-06-16 | 2003-06-16 | 23FS+183d | 192d | 0d |  |  |
| 25 | 1.1.23 | Assembly/Installation PAR | milestone | 0d | 2004-02-16 | 2004-02-16 |  | 476d |  | start no earlier than 2004-02-16 |  |
| 26 | 1.1.24 | Beam Pipe FDR | milestone | 0d | 2002-02-26 | 2002-02-26 |  | 990d |  | start no earlier than 2002-02-26 |  |

| ID | WBS | Task | Type | Duration | Start | Finish | Predecessors | Total slack | Free slack | Constraint |
| --- | --- | --- | --- | --- | --- | --- | --- | --- | --- | --- |
| 27 | 1.1.1.1.2 | **Development/Prototypes** |  | 640d | 2000-09-07 | 2003-02-19 |  | 733d |  |  |
| 28 | 1.2.1 | Stave Development & Prototypes |  | 187d | 2000-10-24 | 2001-07-12 |  | 1153d | 0d | finish no earlier than 2001-07-12 |
| 29 | 1.2.2 | Complete Stave Development | milestone | 0d | 2001-07-12 | 2001-07-12 | 28 | 1153d |  |  |
| 30 | 1.2.3 | Sector development/prototypes |  | 187d | 2000-10-24 | 2001-07-12 | 3FF | 1153d | 0d |  |
| 31 | 1.2.4 | Complete sector development | milestone | 0d | 2001-07-12 | 2001-07-12 | 30 | 1153d |  |  |
| 32 | 1.2.5 | Barrel Shell Development & Prototypes |  | 271d | 2000-10-02 | 2001-10-15 | 7FF+1d | 1085d | 0d | start no earlier than 2000-10-02 |
| 33 | 1.2.6 | Complete Barrel Shell | milestone | 0d | 2001-10-15 | 2001-10-15 | 32 | 1085d |  |  |
| 34 | 1.2.7 | Disk development/prototypes |  | 271d | 2000-10-02 | 2001-10-15 | 7FF | 1085d | 0d | start no earlier than 2000-10-02 |
| 35 | 1.2.8 | Complete disk development | milestone | 0d | 2001-10-15 | 2001-10-15 | 34 | 1085d |  |  |
| 36 | 1.2.9 | Global support development/prototypes |  | 271d | 2000-10-02 | 2001-10-15 | 7FF | 1085d | 0d | start no earlier than 2000-10-02 |
| 37 | 1.2.10 | Complete global support development/prototypes | milestone | 0d | 2001-10-15 | 2001-10-15 | 36 | 1085d |  |  |
| 38 | 1.2.11 | Support tube development/prototypes |  | 240d | 2001-03-27 | 2002-02-26 | 11FF | 990d | 0d |  |
| 39 | 1.2.12 | Support tube development complete | milestone | 0d | 2002-02-26 | 2002-02-26 | 38 | 990d |  |  |
| 40 | 1.2.13 | Internal services development/prototypes |  | 500d | 2000-09-07 | 2002-08-08 | 94SF-40d | 873d | 0d |  |
| 41 | 1.2.14 | Complete internal services development/prototypes | milestone | 0d | 2002-08-08 | 2002-08-08 | 40 | 873d |  |  |
| 42 | 1.2.15 | External services development/prototypes |  | 400d | 2001-08-09 | 2003-02-19 | 20FF | 733d | 0d | start no earlier than 2000-10-02 |
| 43 | 1.2.16 | Compl. External services development/prototypes | milestone | 0d | 2003-02-19 | 2003-02-19 | 42 | 733d |  |  |
| 44 | 1.2.17 | B-layer support development/prototypes |  | 280d | 2001-09-06 | 2002-10-03 | 15FF | 833d | 0d |  |
| 45 | 1.2.18 | Complete B-layer shell prototype | milestone | 0d | 2002-02-26 | 2002-02-26 | 11 | 990d |  |  |
| 46 | 1.2.19 | Complete B-layer support development | milestone | 0d | 2002-10-03 | 2002-10-03 | 44 | 833d |  |  |
| 47 | 1.1.1.1.3 | **Production** |  | 1254d | 2001-02-21 | 2005-12-12 |  | 0d |  |  |
| 48 | 1.3.1 | **Staves** |  | 417d | 2001-11-30 | 2003-07-07 |  | 635d |  |  |
| 49 | 1.3.1.1 | Material Procurements Complete | milestone | 0d | 2001-12-21 | 2001-12-21 |  | 1037d |  | start no earlier than 2001-12-21 |
| 50 | 1.3.1.2 | **Component Manufacturing** |  | 330d | 2001-11-30 | 2003-03-07 |  | 722d |  |  |
| 51 | 1.3.1.2.1 | Omega Complete | milestone | 0d | 2001-11-30 | 2001-11-30 |  | 1052d |  | start no earlier than 2001-11-30 |
| 52 | 1.3.1.2.2 | TMT 10% Ready | milestone | 0d | 2002-02-15 | 2002-02-15 |  | 997d | 120d | start no earlier than 2002-02-15 |
| 53 | 1.3.1.2.3 | TMT 50% Ready | milestone | 0d | 2002-08-02 | 2002-08-02 | 52 | 877d | 155d | start no earlier than 2002-08-02 |
| 54 | 1.3.1.2.4 | TMT 100% Ready | milestone | 0d | 2003-03-07 | 2003-03-07 | 53 | 722d |  | start no earlier than 2003-03-07 |

| ID | WBS | Task | Type | Duration | Start | Finish | Predecessors | Total slack | Free slack | Constraint | Text1 |
| --- | --- | --- | --- | --- | --- | --- | --- | --- | --- | --- | --- |
| 55 | 1.3.1.3 | **Stave Assembly** |  | 361d | 2002-02-18 | 2003-07-07 |  | 635d |  |  |  |
| 56 | 1.3.1.3.1 | 10% |  | 85d | 2002-02-18 | 2002-06-14 |  | 635d | 0d | finish no earlier than 2002-06-14 |  |
| 57 | 1.3.1.3.2 | 10% Complete | milestone | 0d | 2002-06-14 | 2002-06-14 | 56 | 635d | 0d | start no earlier than 2002-06-14 |  |
| 58 | 1.3.1.3.3 | 50% |  | 141d | 2002-06-17 | 2002-12-30 | 57 | 635d | 0d |  |  |
| 59 | 1.3.1.3.4 | 50% Complete | milestone | 0d | 2002-12-30 | 2002-12-30 | 58 | 635d | 0d | start no earlier than 2002-12-30 |  |
| 60 | 1.3.1.3.5 | 100% |  | 135d | 2002-12-31 | 2003-07-07 | 59 | 635d | 0d |  |  |
| 61 | 1.3.2 | Stave production Complete | milestone | 0d | 2003-07-07 | 2003-07-07 | 60 | 635d |  | start no earlier than 2003-07-07 | LHCC |
| 62 | 1.3.3 | 1st Prod Modules Ready to Attach to Staves | milestone | 0d | 2003-12-15 | 2003-12-15 |  | 521d |  | start no earlier than 2003-12-15 |  |
| 63 | 1.3.4 | **Disk Sectors** |  | 389d | 2001-02-21 | 2002-08-19 |  | 865d |  |  |  |
| 64 | 1.3.4.1 | **Major Procurements** |  | 43d | 2001-06-15 | 2001-08-15 |  | 1129d |  |  |  |
| 65 | 1.3.4.1.1 | Receive Adhesive | milestone | 0d | 2001-08-15 | 2001-08-15 |  | 1129d |  | start no earlier than 2001-08-15 |  |
| 66 | 1.3.4.1.2 | Receive Carbon Foam | milestone | 0d | 2001-06-15 | 2001-06-15 |  | 1172d |  | start no earlier than 2001-06-15 |  |
| 67 | 1.3.4.1.3 | Receive Al Tubes | milestone | 0d | 2001-06-28 | 2001-06-28 |  | 1163d |  | start no earlier than 2001-06-28 |  |
| 68 | 1.3.4.1.4 | Receive C Plates | milestone | 0d | 2001-08-06 | 2001-08-06 |  | 1136d |  | start no earlier than 2001-08-06 |  |
| 69 | 1.3.4.2 | **Disk Sector Assy** |  | 389d | 2001-02-21 | 2002-08-19 |  | 865d |  |  |  |
| 70 | 1.3.4.2.1 | Prototype |  | 94d | 2001-02-21 | 2001-07-02 |  | 1160d | 0d | finish no earlier than 2001-07-02 |  |
| 71 | 1.3.4.2.2 | Prototype Complete | milestone | 0d | 2001-07-02 | 2001-07-02 | 70 | 1160d |  |  |  |
| 72 | 1.3.4.2.3 | Pre-Production |  | 163d | 2001-08-06 | 2002-03-20 |  | 973d | 0d | start no earlier than 2001-08-06 |  |
| 73 | 1.3.4.2.4 | Pre-Production Complete | milestone | 0d | 2002-03-20 | 2002-03-20 | 72 | 973d |  |  |  |
| 74 | 1.3.4.2.5 | Production |  | 164d | 2002-01-02 | 2002-08-19 |  | 825d | 0d | start no earlier than 2002-01-02 |  |
| 75 | 1.3.5 | Disk Sector Production Complete | milestone | 0d | 2002-08-19 | 2002-08-19 | 74 | 825d | 66d |  |  |
| 76 | 1.3.6 | 1st Prod Modules Ready to Attach to Sectors | milestone | 0d | 2003-12-15 | 2003-12-15 |  | 521d |  | start no earlier than 2003-12-15 |  |
| 77 | 1.3.7 | **Layer 1/2 Shells** |  | 535d | 2002-03-27 | 2004-04-13 |  | 10d |  |  |  |
| 78 | 1.3.7.1 | Tooling/Fabrication |  | 180d | 2002-03-27 | 2002-12-03 | 8FS+20d | 10d | 0d |  |  |
| 79 | 1.3.7.2 | Fabricate/Test Layer 1 |  | 135d | 2002-07-17 | 2003-01-21 | 78SS+80d | 10d | 0d |  |  |
| 80 | 1.3.7.3 | Fabricate/Test Layer 2 |  | 160d | 2003-09-03 | 2004-04-13 | 90 | 10d | 0d |  |  |
| 81 | 1.3.8 | Barrel Shells Complete | milestone | 0d | 2004-04-13 | 2004-04-13 | 80 | 434d |  |  |  |

| ID | WBS | Task | Type | Duration | Start | Finish | Predecessors | Total slack | Free slack | Text1 |
| --- | --- | --- | --- | --- | --- | --- | --- | --- | --- | --- |
| 82 | 1.3.9 | **Disk Support Rings** |  | 160d | 2002-04-10 | 2002-11-19 |  | 679d |  |  |
| 83 | 1.3.9.1 | Support Rings Fab/Test |  | 160d | 2002-04-10 | 2002-11-19 | 8FS+30d | 679d | 0d |  |
| 84 | 1.3.10 | Disk Support Rings Complete | milestone | 0d | 2002-11-19 | 2002-11-19 | 83 | 679d | 100d |  |
| 85 | 1.3.11 | **Global Support Frame** |  | 260d | 2002-04-10 | 2003-04-08 |  | 579d |  |  |
| 86 | 1.3.11.1 | Support Frame Fab/Test |  | 260d | 2002-04-10 | 2003-04-08 | 8FS+30d | 579d | 0d |  |
| 87 | 1.3.12 | Global Support Frame Complete | milestone | 0d | 2003-04-08 | 2003-04-08 | 86 | 579d | 0d |  |
| 88 | 1.3.13 | **B-Layer Structures** |  | 306d | 2002-07-17 | 2003-09-17 |  | 10d |  |  |
| 89 | 1.3.13.1 | Tooling/Fabrication |  | 135d | 2002-07-17 | 2003-01-21 | 79SS | 10d | 0d |  |
| 90 | 1.3.13.2 | B-Layer Shell Fab/Test |  | 160d | 2003-01-22 | 2003-09-02 | 89 | 10d | 0d |  |
| 91 | 1.3.13.3 | B-Layer Support Tube Fab/Test |  | 130d | 2003-03-20 | 2003-09-17 | 16FS+20d | 443d | 0d |  |
| 92 | 1.3.14 | B-Layer Structure Complete | milestone | 0d | 2003-09-17 | 2003-09-17 | 91 | 583d |  |  |
| 93 | 1.3.15 | **Services Support Panel** |  | 220d | 2002-10-03 | 2003-08-06 |  | 613d |  |  |
| 94 | 1.3.15.1 | Support Panel Fab |  | 220d | 2002-10-03 | 2003-08-06 | 12 | 613d | 0d |  |
| 95 | 1.3.16 | Services Support Panel Complete | milestone | 0d | 2003-08-06 | 2003-08-06 | 94 | 613d |  |  |
| 96 | 1.3.17 | **Pixel Support Tube** |  | 342d | 2002-10-03 | 2004-01-23 |  | 491d |  |  |
| 97 | 1.3.17.1 | Pixel Support Tube Fab |  | 240d | 2002-10-03 | 2003-09-03 | 12 | 491d | 0d |  |
| 98 | 1.3.17.2 | Support Tube Trial Assy |  | 102d | 2003-09-04 | 2004-01-23 | 97 | 491d | 0d |  |
| 99 | 1.3.18 | Pixel Support Tube Complete | milestone | 0d | 2004-01-23 | 2004-01-23 | 98 | 491d |  | LHCC |
| 100 | 1.3.19 | **Assembly/Installation Tooling** |  | 573d | 2002-10-03 | 2004-12-13 |  | 260d |  |  |
| 101 | 1.3.19.1 | Trial Assembly Tooling |  | 130d | 2002-10-03 | 2003-04-02 | 23 | 703d |  |  |
| 102 | 1.3.19.2 | Surface Assembly Tooling |  | 250d | 2003-07-29 | 2004-07-12 | 24FS+30d | 370d | 0d |  |
| 103 | 1.3.19.3 | Installation Tooling |  | 250d | 2003-12-30 | 2004-12-13 | 24FS+140d | 192d | 0d |  |
| 104 | 1.3.20 | Surface assembly tooling complete | milestone | 0d | 2004-07-12 | 2004-07-12 | 102 | 370d |  |  |
| 105 | 1.3.21 | Installation Tooling Complete | milestone | 0d | 2004-12-13 | 2004-12-13 | 103 | 260d |  |  |

| ID | WBS | Task | Type | Duration | Start | Finish | Predecessors | Total slack | Free slack | Constraint | Text1 |
| --- | --- | --- | --- | --- | --- | --- | --- | --- | --- | --- | --- |
| 106 | 1.3.22 | **Trial Assembly** |  | 256d | 2003-04-09 | 2004-03-31 |  | 443d |  |  |  |
| 107 | 1.3.22.1 | Support Frame/Disks |  | 120d | 2003-04-09 | 2003-09-23 | 87, 84 | 579d | 0d |  |  |
| 108 | 1.3.22.2 | Barrel Shells/B-Layer |  | 60d | 2003-09-18 | 2003-12-10 | 91, 79 | 443d | 0d |  |  |
| 109 | 1.3.22.3 | Tube/Frame/Panels |  | 80d | 2003-12-11 | 2004-03-31 | 108 | 443d | 0d |  |  |
| 110 | 1.3.23 | Support Frame Ready | milestone | 0d | 2003-09-23 | 2003-09-23 | 107 | 579d |  |  | LHCC |
| 111 | 1.3.24 | Trial Assembly Complete | milestone | 0d | 2004-03-31 | 2004-03-31 | 109 | 443d |  |  |  |
| 112 | 1.3.25 | **Internal Services** |  | 340d | 2003-02-20 | 2004-06-09 |  | 393d |  |  |  |
| 113 | 1.3.25.1 | Procurement & Fab Services |  | 260d | 2003-02-20 | 2004-02-18 | 20 | 393d | 0d |  |  |
| 114 | 1.3.25.2 | Load Services Support Panels |  | 280d | 2003-05-15 | 2004-06-09 | 113SS+60d | 393d | 0d |  |  |
| 115 | 1.3.26 | Internal Services Complete | milestone | 0d | 2004-06-09 | 2004-06-09 | 114 | 393d |  |  |  |
| 116 | 1.3.27 | **External Services** |  | 362d | 2003-06-12 | 2004-10-29 |  | 291d |  |  |  |
| 117 | 1.3.27.1 | Procurement & Fab |  | 300d | 2003-06-12 | 2004-08-04 | 20FS+80d | 291d | 0d |  |  |
| 118 | 1.3.27.2 | Installation of External Services |  | 109d | 2004-06-01 | 2004-10-29 | 117SS+253d | 291d | 0d |  |  |
| 119 | 1.3.28 | External Services Complete | milestone | 0d | 2004-10-29 | 2004-10-29 | 118 | 291d |  |  |  |
| 120 | 1.3.29 | **Barrel Assembly/Test** |  | 348d | 2004-04-14 | 2005-08-12 |  | 10d |  |  |  |
| 121 | 1.3.29.1 | Layer 1 Assembly |  | 100d | 2005-03-28 | 2005-08-12 | 79, 122FS+140d | 10d | 0d | start no earlier than 2004-01-05 |  |
| 122 | 1.3.29.2 | Layer 2 Assembly |  | 108d | 2004-04-14 | 2004-09-10 | 80 | 10d | 0d |  |  |
| 123 | 1.3.30 | Layer 1 @ CERN | milestone | 0d | 2005-08-26 | 2005-08-26 | 121FS+10d | 10d |  |  |  |
| 124 | 1.3.31 | Layer 2 @ CERN | milestone | 0d | 2004-09-24 | 2004-09-24 | 122FS+10d | 60d | 0d |  |  |
| 125 | 1.3.32 | **Disk Assembly/Test** |  | 723d | 2002-11-20 | 2005-08-26 |  | 76d |  |  |  |
| 126 | 1.3.32.1 | Trial Assembly |  | 40d | 2002-11-20 | 2003-01-14 | 83, 75 | 759d |  |  |  |
| 127 | 1.3.32.2 | Disk A1 |  | 45d | 2004-01-05 | 2004-03-05 |  | 0d |  | start no earlier than 2004-01-05 |  |
| 128 | 1.3.32.3 | Disk C1 |  | 45d | 2004-03-08 | 2004-05-07 | 127 | 0d |  |  |  |
| 129 | 1.3.32.4 | Disk A3 |  | 45d | 2004-05-10 | 2004-07-09 | 128 | 0d |  |  |  |
| 130 | 1.3.32.5 | Disk C3 |  | 45d | 2004-07-12 | 2004-09-10 | 129 | 0d |  |  |  |
| 131 | 1.3.32.6 | Disk A2 |  | 45d | 2005-04-25 | 2005-06-24 | 130FS+160d | 0d |  |  |  |
| 132 | 1.3.32.7 | Disk C2 |  | 45d | 2005-06-27 | 2005-08-26 | 131 | 0d |  |  |  |
| 133 | 1.3.33 | Initial Disk System @CERN | milestone | 0d | 2004-09-24 | 2004-09-24 | 130FS+10d | 60d | 0d |  |  |
| 134 | 1.3.34 | Remainder of Disk System @ CERN | milestone | 0d | 2005-09-09 | 2005-09-09 | 132FS+10d | 0d |  |  |  |

| ID | WBS | Task | Type | Duration | Start | Finish | Predecessors | Total slack | Free slack | Constraint | Text1 |
| --- | --- | --- | --- | --- | --- | --- | --- | --- | --- | --- | --- |
| 135 | 1.3.35 | **B-Layer Assembly/Test** |  | 60d | 2004-09-29 | 2004-12-21 |  | 68d |  |  |  |
| 136 | 1.3.35.1 | B-layer modules ready | milestone | 0d | 2004-09-29 | 2004-09-29 |  | 68d | 0d | start no earlier than 2004-09-29 |  |
| 137 | 1.3.35.2 | B-Layer Assembly |  | 60d | 2004-09-29 | 2004-12-21 | 136 | 68d | 0d | start no earlier than 2004-09-27 |  |
| 138 | 1.3.36 | B-Layer Assembly Complete | milestone | 0d | 2004-12-21 | 2004-12-21 | 137 | 68d | 0d |  |  |
| 139 | 1.3.37 | **CERN Surface Assy/Test/Survey** |  | 123d | 2004-09-27 | 2005-03-16 |  | 60d |  |  |  |
| 140 | 1.3.37.1 | Initial Barrel Assembly/Test |  | 30d | 2004-09-27 | 2004-11-05 | 124 | 60d | 0d |  |  |
| 141 | 1.3.37.2 | Initial Disk Assembly/Test |  | 30d | 2004-09-27 | 2004-11-05 | 133 | 60d | 0d |  |  |
| 142 | 1.3.37.3 | Barrel/Disk Assembly & Survey |  | 40d | 2004-11-08 | 2004-12-31 | 140, 141 | 60d | 0d |  |  |
| 143 | 1.3.37.4 | Beam pipe available | milestone | 0d | 2004-11-08 | 2004-11-08 | 144SS-40d | 286d |  |  |  |
| 144 | 1.3.37.5 | Insert beam pipe |  | 2d | 2005-01-03 | 2005-01-04 | 142 | 244d | 0d |  |  |
| 145 | 1.3.37.6 | B-Layer Insertion/Survey/Test |  | 10d | 2005-01-05 | 2005-01-18 | 138FS+10d | 68d | 8d |  |  |
| 146 | 1.3.37.7 | Service Panel Integration/Test |  | 60d | 2004-11-08 | 2005-01-28 | 142SS | 60d | 0d |  |  |
| 147 | 1.3.37.8 | System Test |  | 33d | 2005-01-31 | 2005-03-16 | 146, 145 | 60d | 0d |  |  |
| 148 | 1.3.38 | Initial Pixel System Ready for Install | milestone | 0d | 2005-03-16 | 2005-03-16 | 147 | 60d | 0d |  | LHCC |
| 149 | 1.3.39 | Third layer ready to install | milestone | 0d | 2005-12-12 | 2005-12-12 | 134FS+66d, 123FS+66d | 0d |  |  | LHCC |
| 150 | 1.3.40 | **Installation** |  | 68d | 2005-06-16 | 2005-09-19 |  | 60d |  |  |  |
| 151 | 1.3.40.1 | Erect installation tooling |  | 5d | 2005-06-16 | 2005-06-22 | 103, 148FS+65d | 60d | 0d |  |  |
| 152 | 1.3.40.2 | Lower Into Pit |  | 2d | 2005-06-23 | 2005-06-24 | 151 | 60d | 0d |  |  |
| 153 | 1.3.40.3 | Slide into Support Tube |  | 2d | 2005-06-27 | 2005-06-28 | 152 | 60d | 0d |  |  |
| 154 | 1.3.40.4 | Services Connection & Initial Test |  | 22d | 2005-06-29 | 2005-07-28 | 153 | 60d | 0d |  |  |
| 155 | 1.3.40.5 | Initial Commission |  | 37d | 2005-07-29 | 2005-09-19 | 154 | 60d |  |  |  |
| 156 | 1.3.41 | Initial Pixel Installation Complete | milestone | 0d | 2005-07-28 | 2005-07-28 | 154 | 97d |  |  |  |
