# production barrels

Schedule from MS Project, 2002-03-04 to 2003-09-15.
IVW GmbH

## Calendars

- Standard: Mon-Thu 08:00-12:00, 13:00-17:00; Fri-Sun off. Exceptions (off unless hours are given): 2002-06-12 to 2002-06-13, 2002-06-14 08:00-12:00, 13:00-17:00, 2002-06-17 to 2002-06-27, 2002-09-11 to 2002-09-12, 2002-09-16 to 2002-09-26, 2002-11-13 to 2002-11-14, 2002-11-18 to 2002-11-28, 2003-02-12 to 2003-02-27, 2003-06-11 to 2003-06-26.

## Schedule

| ID | WBS | Task | Type | Duration | Start | Finish | Predecessors | Baseline start | Baseline finish | Baseline duration | Total slack | Free slack | Constraint |
| --- | --- | --- | --- | --- | --- | --- | --- | --- | --- | --- | --- | --- | --- |
| 1 | 1 | PRR layer 1 und 2 | milestone | 1d | 2002-03-04 | 2002-03-04 |  | 2002-02-26 | 2002-02-26 | 1d? | 271d |  |  |
| 2 | 2 | CDR B-layer | milestone | 1d | 2002-03-04 | 2002-03-04 |  | 2002-02-26 | 2002-02-26 | 1d? | 271d |  |  |
| 3 | 3 | FDR B-layer | milestone | 1d | 2002-06-14 | 2002-06-14 |  | 2002-02-26 | 2002-02-26 | 1d? | 213d |  | start no earlier than 2002-06-14 |
| 4 | 4 | PRR B-layer | milestone | 1d | 2002-10-03 | 2002-10-03 |  | 2002-02-26 | 2002-02-26 | 1d? | 167d |  | start no earlier than 2002-10-03 |
| 5 | 5 | **b-layer developement** |  | 55d | 2002-03-04 | 2002-06-05 |  | 2002-02-26 | 2002-02-26 | 1d? | 43d |  |  |
| 6 | 5.1 | **design, techn. Drawings** |  | 50d | 2002-03-04 | 2002-05-28 |  | 2002-02-26 | 2002-02-26 | 1d? | 43d |  |  |
| 7 | 5.1.1 | B-layer support structure |  | 30d | 2002-03-04 | 2002-04-23 |  | 2002-02-26 | 2002-02-26 | 1d? | 43d | 0d |  |
| 8 | 5.1.2 | jigs |  | 20d | 2002-04-24 | 2002-05-28 | 7 | 2002-02-26 | 2002-02-26 | 1d? | 43d | 0d |  |
| 9 | 5.2 | FE analyses |  | 20d | 2002-05-02 | 2002-06-05 | 7, 8FS-15d | 2002-02-26 | 2002-02-26 | 1d? | 217d |  |  |
| 10 | 6 | **production of all layers parallel (higher priority on layer 1 and 2)** |  | 271d | 2002-03-04 | 2003-09-11 |  | 2002-02-26 | 2002-11-04 | 180d? | 0d |  |  |
| 11 | 6.1 | material procurement (CF-PEEK, prepreg) |  | 1d | 2002-03-04 | 2002-03-04 |  | 2002-02-26 | 2002-02-26 | 1d | 0d |  |  |
| 12 | 6.2 | **Tooling/fabrication** |  | 213d | 2002-03-04 | 2003-05-15 |  | 2002-02-26 | 2002-11-04 | 180d | 49d |  |  |
| 13 | 6.2.1 | flat plate |  | 2d | 2002-03-04 | 2002-03-05 |  | 2002-02-26 | 2002-02-27 | 2d | 49d | 33d |  |
| 14 | 6.2.2 | graphite tools (outer halfshell) |  | 15d | 2002-05-02 | 2002-05-28 | 13, 8FS-15d | 2002-02-28 | 2002-03-20 | 15d | 43d | 0d |  |
| 15 | 6.2.3 | graphite tools (inner skins) |  | 15d | 2002-05-29 | 2002-07-09 | 14 | 2002-03-21 | 2002-04-10 | 15d | 43d | 0d |  |
| 16 | 6.2.4 | halfring drilling jigs |  | 5d | 2002-07-10 | 2002-07-17 | 15 | 2002-04-11 | 2002-04-17 | 5d | 43d | 0d |  |
| 17 | 6.2.5 | halfring bonding and milling jigs |  | 15d | 2002-07-18 | 2002-08-13 | 16 | 2002-04-18 | 2002-05-08 | 15d | 43d | 0d |  |
| 18 | 6.2.6 | outer shell bonding and machining jig |  | 25d | 2002-08-14 | 2002-10-14 | 17 | 2002-05-09 | 2002-06-12 | 25d | 43d | 0d |  |
| 19 | 6.2.7 | inner skin machining jig |  | 25d | 2002-10-15 | 2002-12-12 | 18 | 2002-06-13 | 2002-07-17 | 25d | 43d | 0d |  |
| 20 | 6.2.8 | halfshell structure bonding jigs |  | 40d | 2002-12-16 | 2003-03-11 | 19 | 2002-07-18 | 2002-09-11 | 40d | 43d | 0d |  |
| 21 | 6.2.9 | jigs for measurement as-aligned geometry (eventually used for stave mounting and assembling) |  | 33d | 2003-03-12 | 2003-05-07 | 20 | 2002-09-12 | 2002-10-28 | 33d | 43d | 0d |  |
| 22 | 6.2.10 | jigs for measurement of load test |  | 5d | 2003-05-08 | 2003-05-15 | 21 | 2002-10-29 | 2002-11-04 | 5d | 54d | 0d |  |
| 23 | 6.3 | **Fabrication** |  | 195d | 2002-04-25 | 2003-06-09 |  | 2002-02-26 | 2002-05-23 | 63d? | 30d |  |  |
| 24 | 6.3.1 | CF-PEEK plate production |  | 10d | 2002-04-25 | 2002-05-13 | 11FS+30d | 2002-02-26 | 2002-02-26 | 1d? | 191d | 0d |  |
| 25 | 6.3.2 | machining of CF-PEEK parts |  | 40d | 2002-05-14 | 2002-08-06 | 24 | 2002-02-26 | 2002-02-26 | 1d? | 191d |  |  |
| 26 | 6.3.3 | flat plate production (layer 1, 2, B-layer) |  | 40d | 2002-07-03 | 2002-09-10 | 11FS+60d, 13FS+10d | 2002-05-22 | 2002-05-22 | 1d? | 0d |  |  |
| 27 | 6.3.4 | waterjet pre cutting of halfring faceplates (layer 1, 2, B-layer) |  | 15d | 2002-10-16 | 2002-11-11 | 26, 42 | 2002-05-23 | 2002-05-23 | 1d? | 0d |  |  |
| 28 | 6.3.5 | manufacturing of halfshells (layer 1, layer 2, B-layer) |  | 40d | 2002-11-12 | 2003-02-05 | 14FS+20d, 35, 11FS+60d, 27 | 2002-04-18 | 2002-04-18 | 1d? | 0d |  |  |
| 29 | 6.3.6 | manufacturing of inner skins (layer 1, layer 2, B-layer) |  | 40d | 2003-02-06 | 2003-05-05 | 28 | 2002-02-26 | 2002-02-26 | 1d? | 0d |  |  |
| 30 | 6.3.7 | machining of halfshells and inner skins (layer 1, layer 2, B-layer) |  | 20d | 2003-05-06 | 2003-06-09 | 29, 18, 19 | 2002-02-26 | 2002-02-26 | 1d? | 0d |  |  |

| ID | WBS | Task | Type | Duration | Start | Finish | Predecessors | Baseline start | Baseline finish | Baseline duration | Total slack | Free slack |
| --- | --- | --- | --- | --- | --- | --- | --- | --- | --- | --- | --- | --- |
| 31 | 6.4 | **Assembling** |  | 130d | 2002-11-12 | 2003-08-18 |  | 2002-02-26 | 2002-02-26 | 1d? | 0d |  |
| 32 | 6.4.1 | halfrings (bonding and machining) |  | 45d | 2002-11-12 | 2003-03-04 | 36, 27 | 2002-02-26 | 2002-02-26 | 1d? | 50d | 0d |
| 33 | 6.4.2 | halfshell structures |  | 30d | 2003-06-10 | 2003-08-18 | 32, 30, 37, 43 | 2002-02-26 | 2002-02-26 | 1d? | 0d |  |
| 34 | 6.5 | **Qualification test of jigs** |  | 153d | 2002-07-10 | 2003-05-26 |  | 2002-02-26 | 2002-02-26 | 1d? | 54d |  |
| 35 | 6.5.1 | graphite tools |  | 5d | 2002-07-10 | 2002-07-17 | 15 | 2002-02-26 | 2002-02-26 | 1d? | 56d |  |
| 36 | 6.5.2 | halfring bonding and milling jigs |  | 5d | 2002-08-14 | 2002-08-21 | 17 | 2002-02-26 | 2002-02-26 | 1d? | 86d | 36d |
| 37 | 6.5.3 | halfshell structure bonding jigs |  | 5d | 2003-03-12 | 2003-03-19 | 20 | 2002-02-26 | 2002-02-26 | 1d? | 46d |  |
| 38 | 6.5.4 | jigs for measurement as-aligned geometry |  | 5d | 2003-05-08 | 2003-05-15 | 21 | 2002-02-26 | 2002-02-26 | 1d? | 43d |  |
| 39 | 6.5.5 | jigs for measurement under load |  | 5d | 2003-05-19 | 2003-05-26 | 22 |  |  |  | 54d |  |
| 40 | 6.6 | **Qualification of materials, halfrings, halfshells and complete structures** |  | 216d | 2002-06-06 | 2003-09-11 |  |  |  |  | 1d |  |
| 41 | 6.6.1 | CF-PEEK |  | 5d | 2002-06-06 | 2002-07-01 | 24FS+14d |  |  |  | 212d |  |
| 42 | 6.6.2 | CFRP |  | 10d | 2002-09-30 | 2002-10-15 | 26 |  |  |  | 0d |  |
| 43 | 6.6.3 | halfrings |  | 5d | 2003-03-05 | 2003-03-12 | 32 |  |  |  | 50d |  |
| 44 | 6.6.4 | halfshells (as aligned) |  | 5d | 2003-08-19 | 2003-08-26 | 33, 38 |  |  |  | 0d |  |
| 45 | 6.6.5 | shells under load |  | 5d | 2003-08-27 | 2003-09-03 | 44 |  |  |  | 0d |  |
| 46 | 6.6.6 | cool down |  | 5d | 2003-09-04 | 2003-09-11 | 45 |  |  |  | 0d |  |
| 47 | 7 | All shells manufactured and tested | milestone | 1d | 2003-09-15 | 2003-09-15 | 46 |  |  |  | 0d |  |
